# Leccion 1-1 - 3

Schedule from MS Project, 2007-10-26 to 2009-02-05, 9 hours a day, costs in $, A marks actual dates.
Heinz, Silvi, Keren, Josi & Manu

## Calendars

- Estándar: Mon-Fri 09:00-13:00, 15:00-19:00; Sat-Sun off. Exceptions (off unless hours are given): 2007-10-30 08:00-12:00, 13:00-17:00, 2008-05-01.

## Resources

| Resource | Rate |
| --- | --- |
| Oficial | 18 |
| Ayudante | 14 |
| Cemento | 0.34 |
| Arena | 18 |
| Motoniveladora |  |
| Ramón Perez | 25 |

## Schedule

| ID | WBS | Task | Duration | Start | Finish | Predecessors | Complete | Baseline start | Baseline finish | Baseline duration | Total slack | Free slack | Constraint | Deadline | Resources | Work | Actual work | Cost | Baseline cost | Actual cost |
| --- | --- | --- | --- | --- | --- | --- | --- | --- | --- | --- | --- | --- | --- | --- | --- | --- | --- | --- | --- | --- |
| 1 | 1 | Replantear cimientos | 1mo | 2007-10-26 A | 2007-11-27 A |  | 100% | 2007-10-26 | 2007-11-27 | 1mo |  |  |  |  | Oficial | 180h | 180h | 3,240 | 3,240 | 3,240 |
| 2 | 2 | Excavar zanjas | 0.6mo | 2007-11-27 A | 2007-12-14 A | 1 | 100% | 2007-11-27 | 2007-12-14 | 0.6mo |  |  |  |  | Ayudante [1000%] | 1080h | 1080h | 15,120 | 15,120 | 15,120 |
| 3 | 3 | Preparar armaduras | 2mo | 2008-07-01 A | 2008-09-01 A |  | 100% | 2008-06-24 | 2008-08-28 | 2.09mo |  |  | as late as possible |  | Oficial [250%]; Ayudante [125%] | 1350h | 1350h | 22,500 | 22,500 | 22,500 |
| 4 | 4 | **Preparar moldes** | 130.22d | 2007-12-17 A | 2008-07-09 A |  | 100% | 2007-12-17 | 2008-07-09 | 130.22d |  |  |  |  |  | 540h | 540h | 9,720 | 9,720 | 9,720 |
| 5 | 4.1 | Preparar tableros | 2mo | 2007-12-17 A | 2008-02-15 A | 1, 2SS | 100% | 2007-12-17 | 2008-02-15 | 2mo |  |  | start no earlier than 2007-12-17 |  | Oficial | 360h | 360h | 6,480 | 6,480 | 6,480 |
| 6 | 4.2 | Colocar tableros | 1mo | 2008-06-09 A | 2008-07-09 A | 5, 2 | 100% | 2008-06-09 | 2008-07-09 | 1mo |  |  | start no earlier than 2008-06-09 |  | Oficial | 180h | 180h | 3,240 | 3,240 | 3,240 |
| 7 | 5 | Colocar armaduras | 3mo | 2008-08-13 A | 2008-11-14 A | 3SS+7%, 6SS+7% | 100% | 2008-08-08 | 2008-11-11 | 3mo |  |  |  |  | Oficial [200%]; Ayudante [200%] | 2160h | 2160h | 34,560 | 34,560 | 34,560 |
| 8 | 6 | Colar hormigón | 1.6mo | 2008-11-17 | 2009-01-05 | 7 |  | 2008-11-11 | 2008-12-31 | 1.6mo | -3.11d | 0d |  |  | Oficial [125%]; Cemento [125000%]; Arena [25800%] | 360h |  | 11,549 | 11,549 |  |
| 9 | 7 | Imprevistos | 1mo | 2009-01-06 | 2009-02-05 | 8 |  | 2008-12-31 | 2009-01-30 | 1mo | -3.11d | 0d |  | 2009-01-30 |  |  |  |  |  |  |
