# Tarea Fija

Schedule from MS Project, 2007-12-03 to 2009-06-11, 9 hours a day, costs in $.
Heinz, Silvi, Keren, Josi & Manu

## Calendars

- Estándar: Mon-Fri 09:00-13:00, 15:00-19:00; Sat-Sun off.

## Resources

| Resource | Rate |
| --- | --- |
| Arena | 20 |
| Cemento | 0.38 |
| Cal | 0.34 |
| Cemento de Albañilería | 0.34 |
| Hierro | 8 |
| Piedra | 25 |
| Clavos | 6.5 |
| Alambre | 6.5 |
| Oficial | 8.5 |
| Ayudante | 4.5 |
| Trompo | 20 |
| Camión | 75 |
| Retroexcavadora | 85 |
| Enseres de Obra Indeterminados | 2.5 |
| Pegamento Cerámicos | 0.3 |
| Cemento blanco | 0.32 |
| Azulejos 15 x 15 | 15 |
| Baldosa 30 x 30 | 45 |
| Fe 10 | 8 |
| Bloque de Hormigón 10 x 20 x 40 1 cara vista | 1.15 |
| Bloque de Hormigón 20 x 20 x 40 1 cara vista | 1.55 |
| Bloque de Hormigón 10 x 20 x 40 2 caras vista | 1.25 |
| Bloque de Hormigón 20 x 20 x 40 2 caras vista | 1.75 |
| Bloque de Hormigón 10 x 19 x39 | 0.95 |
| Bloque de Hormigón 20 x 19 x 39 | 1.1 |
| Hidrófugo | 4.5 |
| Ladrillo común | 0.4 |
| Cascote de Ladrillos molidos. | 50 |
| Pastina para Cerámicos | 2.5 |
| Cerámico 30 x 30 | 19 |
| Adoquines | 25 |
| Ingeniero | 60 |
| Subcontrato Mano de Obra Pintura | 5 |
| Subcontrato Materiales Pintura | 3 |
| Fe 8 | 6 |
| Fe 4,2 | 5 |
| Canto Rodado | 25 |
| Tabla | 22.5 |

## Schedule

| ID | WBS | Task | Duration | Start | Finish | Predecessors | Total slack | Free slack | Deadline | Resources | Work | Cost |
| --- | --- | --- | --- | --- | --- | --- | --- | --- | --- | --- | --- | --- |
| 1 | 1 | **Tareas Preliminares** | 15.78d | 2007-12-03 | 2007-12-26 |  | -6.84d | 0d |  |  | 174.92h | 3,779.2 |
| 2 | 1.1 | Desmonte de Tierra Vegetal a mano | 100.8h | 2007-12-03 | 2007-12-19 |  | -6.84d | 0d |  | Ayudante; Camión [2%] | 102.82h | 604.8 |
| 3 | 1.2 | Bases | 41.2h | 2007-12-19 | 2007-12-26 | 2 | -6.84d | 0d |  | Piedra [335%]; Arena [335%]; Cemento [3605%]; Enseres de Obra Indeterminados [1545%]; Fe 10 [30900%]; Alambre [155%]; Oficial; Ayudante [75%] | 72.1h | 3,174.4 |
| 4 | 2 | **Aislaciones y Carpetas** | 2.73d | 2008-08-01 | 2008-08-06 |  | -6.84d | 0d |  |  |  |  |
| 5 | 2.1 | Capa aisladora horizontal en muros | 3.16h | 2008-08-01 | 2008-08-01 | 8 | -6.84d | 0d |  |  |  |  |
| 6 | 2.2 | Carpeta Alisada de cemento | 21.39h | 2008-08-01 | 2008-08-06 | 5 | 196.6d |  |  |  |  |  |
| 7 | 3 | **Mamposterías** | 338.62d | 2007-12-26 | 2009-06-11 |  | -6.84d | 0d |  |  |  |  |
| 8 | 3.1 | Mampostería de Ladrillos Comunes en Recalce de Muros | 1253.6h | 2007-12-26 | 2008-08-01 | 3 | -6.84d | 0d |  |  |  |  |
| 9 | 3.2 | Mampostería de Ladrillos Comunes en Elevación | 1582.56h | 2008-08-01 | 2009-05-06 | 5 | -6.84d | 0d |  |  |  |  |
| 10 | 3.3 | Mampostería de Ladrillos Comunes en elevación - Muros Comunes | 58.22h | 2009-05-06 | 2009-05-15 | 9 | -6.84d | 0d |  |  |  |  |
| 11 | 3.4 | Imprevistos | 150h | 2009-05-15 | 2009-06-11 | 10 | -6.84d | 0d | 2009-06-01 |  |  |  |
